# 118,000 SF Tilt-Wall Distribution Warehouse

Schedule from Primavera P6, 2026-07-20 to 2027-06-16, data date 2026-12-01, A marks actual dates.

## Calendars

- BSA_5D_8H_HOL_US: Mon-Fri 07:00-15:00; Sat-Sun off. Exceptions (off unless hours are given): 2026-09-07, 2026-10-12, 2026-11-11, 2026-11-26, 2026-12-25, 2027-01-01, 2027-01-18, 2027-02-15, 2027-05-31.

## Schedule

| ID | WBS | Activity | Type | Duration | Start | Finish | Predecessors | Complete | Remaining | Total float | Phase | Discipline | Responsibility |
| --- | --- | --- | --- | --- | --- | --- | --- | --- | --- | --- | --- | --- | --- |
|  | WDH-001.MIL | **Milestones** |  |  | 2026-07-20 | 2027-06-16 |  |  |  |  |  |  |  |
| MIL-00010 |  | Notice to Proceed (NTP) | milestone | 0d | 2026-07-20 A | 2026-07-20 A |  | 100% |  |  | MLS | PMG | OWN |
| MIL-00060 |  | Long-Lead POs Issued | milestone | 0d | 2026-07-22 A | 2026-07-22 A | PRO-00010, PRO-00040, PRO-00070 | 100% |  |  | MLS | PMG | EPC |
| MIL-00070 |  | All Long-Lead Equipment On Site | milestone | 0d | 2026-12-14 | 2026-12-14 | PRO-00030, PRO-00060, PRO-00090 |  |  | 102d | MLS | PMG | GC |
| MIL-00020 |  | Mechanical Completion | milestone | 0d | 2027-05-11 | 2027-05-11 | MIL-00070, CON-00130, CON-00150, CON-00160, CON-00200, CON-00220 |  |  | 0d | MLS | PMG | OWN |
| MIL-00030 |  | Substantial Completion | milestone | 0d | 2027-05-25 | 2027-05-25 | COM-00020, COM-00010 |  |  | 0d | MLS | PMG | OWN |
| MIL-00040 |  | Ready for Service | milestone | 0d | 2027-06-02 | 2027-06-02 | COM-00030 |  |  | 0d | MLS | PMG | OWN |
| CLS-00010 |  | Project Closeout |  | 10d | 2027-06-03 | 2027-06-16 | MIL-00040 |  |  | 0d | CLS | PMG | GC |
| MIL-00050 |  | Final Completion | milestone | 0d | 2027-06-16 | 2027-06-16 | CLS-00010 |  |  | 0d | MLS | PMG | OWN |
|  | WDH-001.PRO | **Procurement** |  |  | 2026-07-20 | 2026-12-14 |  |  |  |  |  |  |  |
| PRO-00010 |  | Issue PO — Structural Steel Joists & Deck |  | 3d | 2026-07-20 A | 2026-07-22 A | MIL-00010 | 100% |  |  | PRO | STR | GC |
| PRO-00040 |  | Issue PO — Dock Equipment |  | 3d | 2026-07-20 A | 2026-07-22 A | MIL-00010 | 100% |  |  | PRO | MEC | GC |
| PRO-00070 |  | Issue PO — Main Electrical Switchgear |  | 3d | 2026-07-20 A | 2026-07-22 A | MIL-00010 | 100% |  |  | PRO | ELE | GC |
| PRO-00020 |  | Fabricate & Deliver Structural Steel Joists & Deck |  | 75d | 2026-07-23 A | 2026-11-06 A | MIL-00060 | 100% |  |  | PRO | STR | VND |
| PRO-00050 |  | Fabricate & Deliver Dock Equipment |  | 60d | 2026-07-23 A | 2026-10-16 A | MIL-00060 | 100% |  |  | PRO | MEC | VND |
| PRO-00080 |  | Fabricate & Deliver Main Electrical Switchgear |  | 99d | 2026-07-23 A | 2026-12-14 | MIL-00060 | 90% | 10d | 97d | PRO | ELE | VND |
| PRO-00060 |  | Dock Equipment On Site | milestone | 0d | 2026-10-16 A | 2026-10-16 A | PRO-00050 | 100% |  |  | PRO | MEC | VND |
| PRO-00030 |  | Structural Steel Joists & Deck On Site | milestone | 0d | 2026-11-06 A | 2026-11-06 A | PRO-00020 | 100% |  |  | PRO | STR | VND |
| PRO-00090 |  | Main Electrical Switchgear On Site | milestone | 0d | 2026-12-14 | 2026-12-14 | PRO-00080 |  |  | 97d | PRO | ELE | VND |
|  | WDH-001.CON | **Construction** |  |  | 2026-07-20 | 2027-05-11 |  |  |  |  |  |  |  |
|  | WDH-001.CON.01 | **Site & Civil** |  |  | 2026-07-20 | 2026-08-28 |  |  |  |  |  |  |  |
| CON-00010 |  | Perform Mass Grading & Building Pad |  | 25d | 2026-07-20 A | 2026-08-21 A | MIL-00010 | 100% |  |  | CON | CIV | GC |
| CON-00020 |  | Install Site Utilities — Storm & Sanitary |  | 20d | 2026-08-03 A | 2026-08-28 A | CON-00010 SS+10d | 100% |  |  | CON | CIV | SUB |
| CON-00030 |  | Install Site Utilities — Water & Fire Loop |  | 15d | 2026-08-03 A | 2026-08-21 A | CON-00010 SS+10d | 100% |  |  | CON | CIV | SUB |

Notes:
- MIL-00060: BSA Comments: Inserted by the BSA milestone standard — consolidated long-lead purchase-order release.
- MIL-00070: BSA Comments: Rollup of every long-lead delivery — gates Mechanical Completion (BSA standard milestone set).
- MIL-00030: BSA Comments: Target early April 2027 per owner; confirm exact date with owner and AHJ before schedule baseline.
- CLS-00010: BSA Comments: Project closeout / demobilization — ensures Ready for Service and Final Completion are distinct (BSA standard tail).
- PRO-00010: BSA Comments: 15-week lead; PO issued immediately after NTP to protect delivery before panel erection completes.
- PRO-00040: BSA Comments: 12-week lead for dock levelers, dock seals, and overhead sectional doors.
- PRO-00070: BSA Comments: 20-week lead; switchgear must arrive before interior finishes complete.
- PRO-00020: BSA Comments: 15-week (75 working-day) fabrication and delivery lead time from PO issuance.
- PRO-00050: BSA Comments: 12-week (60 working-day) lead time from PO issuance.
- PRO-00080: BSA Comments: 20-week (100 working-day) fabrication and delivery lead time from PO issuance.
- CON-00010: BSA Comments: Includes rough grading, import/export, subgrade prep, and compaction testing for building pad. Duration assumes 9.2-acre site; confirm soil report.
- CON-00020: BSA Comments: Runs in parallel with spread footings; can begin once grading establishes rough grade in utility corridor.
- CON-00030: BSA Comments: Fire loop requires utility permit and water purveyor approval; confirm lead time with AHJ.

| ID | WBS | Activity | Duration | Start | Finish | Predecessors | Complete | Remaining | Total float | Phase | Discipline | Responsibility |
| --- | --- | --- | --- | --- | --- | --- | --- | --- | --- | --- | --- | --- |
|  | WDH-001.CON.02 | **Concrete & Tilt-Wall** |  | 2026-08-24 | 2026-12-09 |  |  |  |  |  |  |  |
| CON-00040 |  | Excavate & Form Spread Footings | 15d | 2026-08-24 A | 2026-09-14 A | CON-00010 | 100% |  |  | CON | CIV | GC |
| CON-00050 |  | Place Concrete Spread Footings | 10d | 2026-09-15 A | 2026-09-28 A | CON-00040 | 100% |  |  | CON | CIV | GC |
| CON-00060 |  | Pour Warehouse Floor Slab — Sections 1 & 2 (Casting Bed) | 10d | 2026-09-29 A | 2026-10-13 A | CON-00050 | 100% |  |  | CON | CIV | GC |
| CON-00070 |  | Pour Warehouse Floor Slab — Sections 3 & 4 | 10d | 2026-10-14 A | 2026-10-27 A | CON-00060 | 100% |  |  | CON | CIV | GC |
| CON-00080 |  | Cast Tilt-Wall Panels (64 Panels) | 20d | 2026-10-14 A | 2026-11-10 A | CON-00060 | 100% |  |  | CON | STR | SUB |
| CON-00090 |  | Cure Tilt-Wall Panels | 11d | 2026-11-24 A | 2026-12-09 | CON-00080 | 35% | 6.5d | 0d | CON | STR | SUB |
|  | WDH-001.CON.03 | **Structure & Envelope** |  | 2026-12-10 | 2027-02-23 |  |  |  |  |  |  |  |
| CON-00100 |  | Erect Tilt-Wall Panels with Mobile Crane | 15d | 2026-12-10 | 2026-12-31 | CON-00090 |  |  | 0d | CON | STR | SUB |
| CON-00110 |  | Erect Structural Steel Joists & Roof Deck | 15d | 2027-01-04 | 2027-01-25 | CON-00100, PRO-00030 |  |  | 0d | CON | STR | SUB |
| CON-00120 |  | Install TPO Roofing & Insulation | 20d | 2027-01-26 | 2027-02-23 | CON-00110 |  |  | 0d | CON | ARC | SUB |
|  | WDH-001.CON.04 | **Warehouse Interior** |  | 2027-02-24 | 2027-04-06 |  |  |  |  |  |  |  |
| CON-00130 |  | Install ESFR Fire Sprinkler System | 25d | 2027-02-24 | 2027-03-30 | CON-00120 |  |  | 30d | CON | MEC | SUB |
| CON-00140 |  | Install Warehouse Electrical & Lighting | 25d | 2027-02-24 | 2027-03-30 | CON-00120 |  |  | 25d | CON | ELE | SUB |
| CON-00160 |  | Install Dock Equipment & Overhead Doors | 10d | 2027-02-24 | 2027-03-09 | PRO-00060, CON-00120 |  |  | 45d | CON | MEC | SUB |
| CON-00150 |  | Set & Energize Main Electrical Switchgear | 5d | 2027-03-31 | 2027-04-06 | CON-00140, PRO-00090 |  |  | 25d | CON | ELE | SUB |
|  | WDH-001.CON.05 | **Office Buildout** |  | 2027-02-24 | 2027-05-11 |  |  |  |  |  |  |  |
| CON-00170 |  | Frame Metal Stud Walls — Office | 10d | 2027-02-24 | 2027-03-09 | CON-00120, CON-00070 |  |  | 0d | CON | STR | SUB |
| CON-00180 |  | Rough-In MEP — Office | 15d | 2027-03-10 | 2027-03-30 | CON-00170 |  |  | 0d | CON | EIN | SUB |
| CON-00190 |  | Install Drywall, Ceilings & Insulation — Office | 15d | 2027-03-31 | 2027-04-20 | CON-00180 |  |  | 0d | CON | ARC | SUB |
| CON-00200 |  | Install Finishes & Storefront Glazing — Office | 15d | 2027-04-21 | 2027-05-11 | CON-00190 |  |  | 0d | CON | ARC | SUB |
|  | WDH-001.CON.06 | **Site Completion** |  | 2027-01-04 | 2027-02-08 |  |  |  |  |  |  |  |
| CON-00210 |  | Pave Car Court & Truck Court | 15d | 2027-01-04 | 2027-01-25 | CON-00100, CON-00020, CON-00030 |  |  | 65d | CON | CIV | SUB |
| CON-00220 |  | Install Landscaping & Irrigation | 10d | 2027-01-26 | 2027-02-08 | CON-00210 |  |  | 65d | CON | CIV | SUB |

Notes:
- CON-00050: BSA Comments: Includes embedded anchor bolts and ledger seats for tilt panels.
- CON-00060: BSA Comments: First slab sections serve as casting bed for tilt-wall panels. Vapor barrier, under-slab plumbing sleeves, and WWF must be placed first.
- CON-00080: BSA Comments: Panel casting begins as soon as Sections 1 & 2 slab is ready; roughly 3–4 panels poured per day. Embeds, blockouts, and reveal patterns per engineering drawings.
- CON-00090: BSA Comments: 10-working-day cure period modeled as explicit activity; no long lags. Bond breaker applied prior to pour.
- CON-00100: BSA Comments: 3-week panel erection; crane access requires clear truck court. Temporary bracing remains until steel joists are set.
- CON-00110: BSA Comments: Erection begins immediately after panels are up. Steel must be on site (PRO-00030) before erection can start.
- CON-00120: BSA Comments: TPO installation dries in the building, enabling interior work to proceed. Confirm R-value and membrane thickness with architect.
- CON-00130: BSA Comments: ESFR system; requires building dry-in and fire loop water service. Coordinate with fire marshal for hydraulic calc approval.
- CON-00140: BSA Comments: Rough-in and fixture installation; LED high-bay lighting. Runs concurrent with ESFR and dock equipment installation.
- CON-00160: BSA Comments: Dock levelers, dock seals, and sectional doors. Equipment must be on site (PRO-00060).
- CON-00150: BSA Comments: Switchgear must be on site (PRO-00090) and warehouse electrical rough-in substantially complete before setting. Utility company coordination required for energization.
- CON-00180: BSA Comments: Electrical, mechanical, and plumbing rough-ins for 6,500 SF two-story office. Coordinate MEP above ceiling with structural.
- CON-00200: BSA Comments: Includes paint, flooring, millwork, storefront aluminum and glazing. Storefront glazing vendor lead time should be confirmed.
- CON-00210: BSA Comments: After panel erection and crane demobilization; aggregate base and concrete or asphalt paving. Confirm paving section with geotech.
- CON-00220: BSA Comments: Late-job scope after hardscape is complete. Confirm plant palette and irrigation design with civil/landscape architect.

| ID | WBS | Activity | Duration | Start | Finish | Predecessors | Total float | Phase | Discipline | Responsibility |
| --- | --- | --- | --- | --- | --- | --- | --- | --- | --- | --- |
|  | WDH-001.COM | **Commissioning & Closeout** |  | 2027-05-12 | 2027-06-02 |  |  |  |  |  |
| COM-00010 |  | Perform Commissioning & Start-Up | 10d | 2027-05-12 | 2027-05-25 | CON-00130, CON-00150, CON-00160, CON-00200, CON-00220, MIL-00020 | 0d | COM | PMG | GC |
| COM-00020 |  | Complete Punchlist & Final Inspections | 10d | 2027-05-12 | 2027-05-25 | MIL-00020 | 0d | CLS | PMG | GC |
| COM-00030 |  | Execute Project Closeout | 5d | 2027-05-26 | 2027-06-02 | MIL-00030 | 0d | CLS | PMG | GC |

Notes:
- COM-00010: BSA Comments: Includes pre-commissioning checks, MEP systems start-up, fire sprinkler system acceptance test, and electrical point-to-point verification. Open end — no successor; auto-wired to Substantial Completion — review.
- COM-00020: BSA Comments: Certificate of occupancy inspection, AHJ final, and owner punchlist completion. Approximately 3 weeks combined with commissioning.
- COM-00030: BSA Comments: As-built drawings, O&M manuals, warranty letters, and lien releases.

## Activity codes

| Code | Value | Meaning |
| --- | --- | --- |
| Discipline | ARC | Architectural |
| Discipline | CIV | Civil |
| Discipline | EIN | Electrical / Instrumentation |
| Discipline | ELE | Electrical |
| Discipline | MEC | Mechanical |
| Discipline | PMG | Project Management |
| Discipline | STR | Structural |
| Phase | CLS | Closeout |
| Phase | COM | Commissioning |
| Phase | CON | Construction |
| Phase | MLS | Milestone |
| Phase | PRO | Procurement |
| Responsibility | EPC | EPC Contractor |
| Responsibility | GC | General Contractor |
| Responsibility | OWN | Owner / Client |
| Responsibility | SUB | Subcontractor |
| Responsibility | VND | Vendor / Supplier |
