# Custom Single-Family Residence — Texas Hill Country

Schedule from Primavera P6, 2026-08-10 to 2027-02-05, data date 2026-08-10.

## Calendars

- BSA_5D_8H_HOL_US: Mon-Fri 07:00-15:00; Sat-Sun off. Exceptions (off unless hours are given): 2026-09-07, 2026-10-12, 2026-11-11, 2026-11-26, 2026-12-25, 2027-01-01, 2027-01-18.

## Schedule

| ID | WBS | Activity | Type | Duration | Start | Finish | Predecessors | Total float | Phase | Discipline | Responsibility |
| --- | --- | --- | --- | --- | --- | --- | --- | --- | --- | --- | --- |
|  | TRM-001.MIL | **Milestones** |  |  | 2026-08-10 | 2027-02-05 |  |  |  |  |  |
| MIL-00010 |  | Notice to Proceed | milestone | 0d | 2026-08-10 | 2026-08-10 |  | 0d | MLS | PMG | OWN |
| MIL-00020 |  | Foundation Complete | milestone | 0d | 2026-09-28 | 2026-09-28 | CON-00050 | 0d | MLS | PMG | OWN |
| MIL-00030 |  | Framing Complete | milestone | 0d | 2026-10-27 | 2026-10-27 | CON-00080 | 0d | MLS | PMG | OWN |
| MIL-00040 |  | Dry-In / Weather-Tight | milestone | 0d | 2026-10-27 | 2026-10-27 | CON-00090, MIL-00030 | 0d | MLS | PMG | OWN |
| MIL-00050 |  | Frame Inspection Passed | milestone | 0d | 2026-10-28 | 2026-10-28 | CON-00100 | 0d | MLS | PMG | OWN |
| MIL-00060 |  | Certificate of Occupancy | milestone | 0d | 2027-02-03 | 2027-02-03 | CON-00260 | 0d | MLS | PMG | OWN |
| MIL-00070 |  | Final Completion / Owner Closeout | milestone | 0d | 2027-02-05 | 2027-02-05 | CON-00270 | 0d | MLS | PMG | OWN |
|  | TRM-001.CON | **Construction** |  |  | 2026-08-10 | 2027-01-29 |  |  |  |  |  |
|  | TRM-001.CON.01 | **Site Work & Foundation** |  |  | 2026-08-10 | 2026-09-28 |  |  |  |  |  |
| CON-00010 |  | Clear Site and Strip Topsoil |  | 5d | 2026-08-10 | 2026-08-14 | MIL-00010 | 0d | CON | CIV | GC |
| CON-00020 |  | Grade and Compact Building Pad |  | 5d | 2026-08-17 | 2026-08-21 | CON-00010 | 0d | CON | CIV | GC |
| CON-00030 |  | Set Slab Forms and Lay Under-Slab Plumbing |  | 10d | 2026-08-24 | 2026-09-04 | CON-00020 | 0d | CON | CIV | GC |
| CON-00040 |  | Install Post-Tensioned Reinforcing and Pour Slab |  | 10d | 2026-09-08 | 2026-09-21 | CON-00030 | 0d | CON | STR | GC |
| CON-00050 |  | Stress Post-Tensioned Tendons |  | 5d | 2026-09-22 | 2026-09-28 | CON-00040 | 0d | CON | STR | SUB |
|  | TRM-001.CON.02 | **Framing & Envelope** |  |  | 2026-09-29 | 2026-10-27 |  |  |  |  |  |
| CON-00060 |  | Frame Exterior and Interior Walls |  | 10d | 2026-09-29 | 2026-10-13 | MIL-00020 | 0d | CON | STR | GC |
| CON-00070 |  | Frame Roof Structure and Sheathing |  | 5d | 2026-10-14 | 2026-10-20 | CON-00060 | 0d | CON | STR | GC |
| CON-00080 |  | Install Standing-Seam Metal Roof |  | 5d | 2026-10-21 | 2026-10-27 | CON-00070 | 0d | CON | ARC | SUB |
| CON-00090 |  | Install Windows and Exterior Doors |  | 3d | 2026-10-21 | 2026-10-23 | CON-00070 | 2d | CON | ARC | SUB |
|  | TRM-001.CON.03 | **Rough-In & Insulation** |  |  | 2026-10-28 | 2026-11-12 |  |  |  |  |  |
| CON-00100 |  | Perform Frame Inspection |  | 1d | 2026-10-28 | 2026-10-28 | MIL-00040 | 0d | CON | PMG | OWN |
| CON-00110 |  | Install Rough Mechanical (HVAC) |  | 10d | 2026-10-29 | 2026-11-12 | MIL-00050 | 0d | CON | MEC | SUB |
| CON-00120 |  | Install Rough Electrical |  | 10d | 2026-10-29 | 2026-11-12 | MIL-00050 | 0d | CON | ELE | SUB |
| CON-00130 |  | Install Rough Plumbing (Above Slab) |  | 10d | 2026-10-29 | 2026-11-12 | MIL-00050 | 0d | CON | MEC | SUB |

Notes:
- MIL-00010: BSA Comments: Building permit already in hand. NTP anchors to 2026-08-10 per project directive; all work flows forward via CPM from this milestone.
- MIL-00040: BSA Comments: House dried-in once metal roof and all windows/exterior doors are installed, targeting mid-November 2026 per narrative.
- MIL-00050: BSA Comments: City frame inspection gates insulation and drywall start. Allow 1-day inspection activity; milestone fires on pass.
- MIL-00060: BSA Comments: CO targeted late January 2027 per owner/builder; schedule logic drives the date — no hard constraint set.
- CON-00010: BSA Comments: Approximately 1 week per narrative. Includes clearing native cedar/brush typical of Hill Country sites.
- CON-00020: BSA Comments: Building pad included in the 1-week site work duration; modeled as a successor to clearing to show sequence. Combined with clearing = ~1 week total; split for visibility.
- CON-00030: BSA Comments: Under-slab plumbing rough-in by plumbing sub concurrent with form-setting; ~2 weeks combined per narrative.
- CON-00040: BSA Comments: PT reinforcing placed then slab poured; ~2 weeks. Tendons stressed approximately 7–10 days after pour before framing begins.
- CON-00050: BSA Comments: PT stressing crew returns ~7 days after pour once concrete reaches design strength. 1-week activity covers mobilization, stressing, and tail cut.
- CON-00060: BSA Comments: 3-week framing scope split into walls (2 wks) and roof framing (1 wk) for schedule visibility. Experienced crew per narrative.
- CON-00080: BSA Comments: ~1 week per narrative. Specialty subcontractor for standing-seam metal in Hill Country.
- CON-00090: BSA Comments: ~3 days per narrative. Windows and doors delivered to site before install; builder to confirm lead time and pre-order accordingly.
- CON-00100: BSA Comments: City inspection activity. Milestone MIL-00050 fires on completion/pass. If failed, re-inspection adds float consumption — flag as risk.
- CON-00110: BSA Comments: ~2 weeks concurrent with electrical and plumbing rough-ins per narrative.
- CON-00120: BSA Comments: ~2 weeks concurrent with MEP rough-ins. Must follow frame inspection pass.
- CON-00130: BSA Comments: ~2 weeks concurrent with MEP rough-ins. Must follow frame inspection pass.

| ID | WBS | Activity | Duration | Start | Finish | Predecessors | Total float | Phase | Discipline | Responsibility |
| --- | --- | --- | --- | --- | --- | --- | --- | --- | --- | --- |
|  | TRM-001.CON.04 | **Drywall & Interior Finishes** |  | 2026-11-13 | 2027-01-29 |  |  |  |  |  |
| CON-00140 |  | Apply Spray-Foam Insulation | 3d | 2026-11-13 | 2026-11-17 | CON-00110, CON-00120, CON-00130 | 0d | CON | ARC | SUB |
| CON-00150 |  | Hang and Finish Drywall | 10d | 2026-11-18 | 2026-12-02 | CON-00140 | 0d | CON | ARC | SUB |
| CON-00160 |  | Install Cabinets and Countertops | 10d | 2026-12-03 | 2026-12-16 | CON-00150 | 0d | CON | ARC | SUB |
| CON-00170 |  | Install Tile and Stone Finishes | 10d | 2026-12-03 | 2026-12-16 | CON-00150 | 0d | CON | ARC | SUB |
| CON-00180 |  | Install Trim Carpentry and Interior Doors | 7d | 2026-12-17 | 2026-12-28 | CON-00160, CON-00170 | 0d | CON | ARC | SUB |
| CON-00190 |  | Paint Interior and Exterior Primer/Finish | 10d | 2026-12-29 | 2027-01-12 | CON-00180 | 0d | CON | ARC | SUB |
| CON-00200 |  | Install Wood Flooring | 7d | 2027-01-13 | 2027-01-22 | CON-00190 | 0d | CON | ARC | SUB |
| CON-00210 |  | Complete MEP Trim-Out and Fixture Installation | 5d | 2027-01-25 | 2027-01-29 | CON-00200 | 0d | CON | MEC | SUB |
|  | TRM-001.CON.05 | **Exterior Finishes & Site** |  | 2026-10-28 | 2026-11-30 |  |  |  |  |  |
| CON-00220 |  | Install Limestone Masonry Exterior | 15d | 2026-10-28 | 2026-11-18 | MIL-00040 | 41d | CON | STR | SUB |
| CON-00240 |  | Pour Driveway and Flatwork Concrete | 5d | 2026-10-28 | 2026-11-03 | MIL-00040 | 51d | CON | CIV | GC |
| CON-00250 |  | Final Grade, Landscaping, and Irrigation | 7d | 2026-11-04 | 2026-11-13 | CON-00240 | 51d | CON | CIV | SUB |
| CON-00230 |  | Apply Stucco Exterior Finish | 7d | 2026-11-19 | 2026-11-30 | CON-00220 | 41d | CON | ARC | SUB |
|  | TRM-001.CLS | **Closeout** |  | 2027-02-01 | 2027-02-05 |  |  |  |  |  |
| CON-00260 |  | Conduct Punch List and Final Inspections | 3d | 2027-02-01 | 2027-02-03 | CON-00210, CON-00230, CON-00250 | 0d | CLS | PMG | GC |
| CON-00270 |  | Conduct Owner Walkthrough and Deliver Home | 2d | 2027-02-04 | 2027-02-05 | MIL-00060 | 0d | CLS | PMG | OWN |

Notes:
- CON-00140: BSA Comments: ~3 days per narrative. Must follow all rough-in trades to avoid having to cut insulation for re-work.
- CON-00150: BSA Comments: ~2 weeks per narrative.
- CON-00160: BSA Comments: Interior finishes overlap ~6 weeks total. Cabinets/countertops lead; countertop template after cabinet install, then fabrication turnaround ~2 weeks — builder to track as potential float consumer.
- CON-00170: BSA Comments: Runs concurrent with cabinet/countertop scope in separate areas of house.
- CON-00190: BSA Comments: Paint follows trim; overlaps with flooring in sequenced areas.
- CON-00200: BSA Comments: Flooring near-last interior finish to avoid damage from other trades.
- CON-00210: BSA Comments: ~1 week per narrative. Includes HVAC equipment final connections, plumbing fixtures, electrical devices/fixtures, and panel trim. Follows flooring and paint.
- CON-00220: BSA Comments: Limestone veneer on exterior; runs parallel with interior finishes per narrative. Hill Country limestone — confirm material availability and mason crew lead time.
- CON-00240: BSA Comments: Driveway and exterior flatwork; runs parallel with interior finishes. Sequence after rough exterior grading is complete.
- CON-00250: BSA Comments: Final grading, sod/native plantings, and irrigation system per narrative. Runs parallel with late interior finishes.
- CON-00230: BSA Comments: Stucco on non-limestone elevations; follows limestone on those elevations. 3-coat system typical — allow cure time between coats included in duration.
- CON-00260: BSA Comments: ~1 week combined per narrative; split into punch list/inspections (3 days) and owner walkthrough (2 days) for clarity.

## Activity codes

| Code | Value | Meaning |
| --- | --- | --- |
| Discipline | ARC | Architectural |
| Discipline | CIV | Civil |
| Discipline | ELE | Electrical |
| Discipline | MEC | Mechanical |
| Discipline | PMG | Project Management |
| Discipline | STR | Structural |
| Phase | CLS | Closeout |
| Phase | CON | Construction |
| Phase | MLS | Milestone |
| Responsibility | GC | General Contractor |
| Responsibility | OWN | Owner / Client |
| Responsibility | SUB | Subcontractor |
