# FM 2350 Potable Water Booster Pump Station

Schedule from Primavera P6, 2026-08-17 to 2027-06-17, data date 2026-08-17.

## Calendars

- BSA_5D_8H_HOL_US: Mon-Fri 07:00-15:00; Sat-Sun off. Exceptions (off unless hours are given): 2026-09-07, 2026-10-12, 2026-11-11, 2026-11-26, 2026-12-25, 2027-01-01, 2027-01-18, 2027-02-15, 2027-05-31.

## Schedule

| ID | WBS | Activity | Type | Duration | Start | Finish | Predecessors | Total float | Phase | Discipline | Responsibility |
| --- | --- | --- | --- | --- | --- | --- | --- | --- | --- | --- | --- |
|  | WBS-001.MIL | **Milestones** |  |  | 2026-08-17 | 2027-06-17 |  |  |  |  |  |
| MIL-00010 |  | Notice to Proceed | milestone | 0d | 2026-08-17 | 2026-08-17 |  | 0d | MLS | PMG | OWN |
| MIL-00090 |  | Long-Lead POs Issued | milestone | 0d | 2026-08-17 | 2026-08-17 | MIL-00010 | 14d | MLS | PMG | EPC |
| MIL-00100 |  | All Long-Lead Equipment On Site | milestone | 0d | 2027-03-03 | 2027-03-03 | PRO-00030, PRO-00050, PRO-00070 | 30d | MLS | PMG | GC |
| MIL-00050 |  | Mechanical Completion | milestone | 0d | 2027-04-14 | 2027-04-14 | CON-00190, CON-00180, MIL-00100, CON-00050, CON-00120, CON-00150, CON-00170 | 0d | MLS | PMG | OWN |
| MIL-00060 |  | Substantial Completion | milestone | 0d | 2027-05-12 | 2027-05-12 | MIL-00050, COM-00050 | 0d | MLS | PMG | OWN |
| MIL-00070 |  | Ready for Service | milestone | 0d | 2027-06-03 | 2027-06-03 | COM-00060 | 0d | MLS | PMG | OWN |
| CLS-00010 |  | Project Closeout |  | 10d | 2027-06-04 | 2027-06-17 | MIL-00070 | 0d | CLS | PMG | GC |
| MIL-00080 |  | Final Completion | milestone | 0d | 2027-06-17 | 2027-06-17 | COM-00070, CLS-00010 | 0d | MLS | PMG | OWN |
|  | WBS-001.PRO | **Procurement** |  |  | 2026-08-17 | 2027-03-03 |  |  |  |  |  |
| PRO-00010 |  | Prepare and Submit Submittals — All Long-Lead |  | 15d | 2026-08-17 | 2026-09-04 | MIL-00010 | 0d | PRO | PMG | EPC |
| PRO-00020 |  | Fabricate and Deliver Pumps and Motors |  | 90d | 2026-09-08 | 2027-01-19 | MIL-00090, PRO-00010 | 0d | PRO | MEC | VND |
| PRO-00040 |  | Fabricate and Deliver Electrical Switchgear |  | 100d | 2026-09-08 | 2027-02-02 | MIL-00090, PRO-00010 | 5d | PRO | ELE | VND |
| PRO-00060 |  | Fabricate and Deliver Standby Generator |  | 120d | 2026-09-08 | 2027-03-03 | MIL-00090, PRO-00010 | 20d | PRO | ELE | VND |
| PRO-00030 |  | Pumps and Motors On Site | milestone | 0d | 2027-01-19 | 2027-01-19 | PRO-00020 | 0d | PRO | MEC | VND |
| PRO-00050 |  | Electrical Switchgear On Site | milestone | 0d | 2027-02-02 | 2027-02-02 | PRO-00040 | 5d | PRO | ELE | VND |
| PRO-00070 |  | Standby Generator On Site | milestone | 0d | 2027-03-03 | 2027-03-03 | PRO-00060 | 20d | PRO | ELE | VND |
|  | WBS-001.CON | **Construction** |  |  | 2026-08-17 | 2027-04-14 |  |  |  |  |  |
|  | WBS-001.CON.01 | **Site Civil** |  |  | 2026-08-17 | 2026-11-25 |  |  |  |  |  |
| CON-00010 |  | Perform Site Clearing and Grading |  | 15d | 2026-08-17 | 2026-09-04 | MIL-00010 | 35d | CON | CIV | GC |
| CON-00020 |  | Install Site Drainage and Storm Sewer |  | 15d | 2026-09-08 | 2026-09-28 | CON-00010 | 95d | CON | CIV | GC |
| CON-00180 |  | Install Security Fencing and Site Access Gate |  | 10d | 2026-09-08 | 2026-09-21 | CON-00010 | 140d | CON | CIV | GC |
| CON-00190 |  | Place Asphalt Paving and Concrete Flatwork |  | 10d | 2026-11-12 | 2026-11-25 | CON-00020, CON-00110 | 95d | CON | CIV | GC |
|  | WBS-001.CON.02 | **Ground Storage Tank** |  |  | 2026-09-08 | 2027-01-04 |  |  |  |  |  |
| CON-00030 |  | Excavate and Pour GST Foundation |  | 25d | 2026-09-08 | 2026-10-13 | CON-00010 | 70d | CON | CIV | GC |
| CON-00040 |  | Erect Prestressed Concrete GST Shell |  | 40d | 2026-10-14 | 2026-12-10 | CON-00030 | 70d | CON | STR | SUB |
| CON-00050 |  | Install GST Roof, Hatches, and Appurtenances |  | 15d | 2026-12-11 | 2027-01-04 | CON-00040 | 70d | CON | STR | SUB |

Notes:
- MIL-00090: BSA Comments: Inserted by the BSA milestone standard — consolidated long-lead purchase-order release.
- MIL-00100: BSA Comments: Rollup of every long-lead delivery — gates Mechanical Completion (BSA standard milestone set).
- MIL-00060: BSA Comments: Target June 2027; duration-driven by CPM — no hard constraint set.
- CLS-00010: BSA Comments: Project closeout / demobilization — ensures Ready for Service and Final Completion are distinct (BSA standard tail).
- PRO-00010: BSA Comments: Submittals for pumps, switchgear, and generator prepared concurrently and submitted to engineer of record within 3 weeks of NTP.
- PRO-00020: BSA Comments: 18-week lead time per narrative = 90 working days. Chain: NTP -> submittals -> approval (MIL-00020) -> this activity -> pumps on site.
- PRO-00040: BSA Comments: 20-week lead time per narrative = 100 working days after approved submittals.
- PRO-00060: BSA Comments: 24-week lead time per narrative = 120 working days after approved submittals.
- PRO-00030: BSA Comments: Delivery milestone; gates pump installation.
- PRO-00050: BSA Comments: Delivery milestone; gates switchgear setting and electrical rough-in.
- PRO-00070: BSA Comments: Delivery milestone; gates generator pad and electrical connection.
- CON-00010: BSA Comments: Includes rough grading and clearing entire site footprint.
- CON-00180: BSA Comments: Perimeter security fencing; can proceed after rough grading complete.
- CON-00190: BSA Comments: Access road, parking, and equipment pad aprons; installed after all underground utilities complete.
- CON-00030: BSA Comments: 1.5 MG prestressed concrete GST foundation slab and ring wall; allow cure time within duration.
- CON-00040: BSA Comments: Specialty prestressed concrete tank contractor; wire wrap and gunite included.
- CON-00050: BSA Comments: Includes overflow pipe, vent, level instrumentation rough-in, and interior coatings prep.

| ID | WBS | Activity | Duration | Start | Finish | Predecessors | Total float | Phase | Discipline | Responsibility |
| --- | --- | --- | --- | --- | --- | --- | --- | --- | --- | --- |
|  | WBS-001.CON.03 | **Pump Station Building** |  | 2026-09-08 | 2027-02-09 |  |  |  |  |  |
| CON-00060 |  | Excavate and Pour Pump Station Foundation | 15d | 2026-09-08 | 2026-09-28 | CON-00010 | 35d | CON | CIV | GC |
| CON-00070 |  | Erect CMU Pump Station Building Structure | 25d | 2026-09-29 | 2026-11-03 | CON-00060 | 35d | CON | STR | GC |
| CON-00080 |  | Install Pump Station Roof and Building Envelope | 15d | 2026-11-04 | 2026-11-25 | CON-00070 | 35d | CON | ARC | GC |
| CON-00090 |  | Set and Grout Vertical Turbine Pumps | 15d | 2027-01-20 | 2027-02-09 | CON-00080, PRO-00030 | 0d | CON | MEC | SUB |
|  | WBS-001.CON.04 | **Yard Piping** |  | 2026-09-29 | 2027-03-17 |  |  |  |  |  |
| CON-00110 |  | Install Yard Piping — 16-inch and 12-inch Mains | 30d | 2026-09-29 | 2026-11-10 | CON-00010, CON-00020 | 95d | CON | PIP | GC |
| CON-00100 |  | Install Pump Station Piping and Valves | 20d | 2027-02-10 | 2027-03-10 | CON-00090 | 0d | CON | PIP | GC |
| CON-00120 |  | Perform 16-inch Hot-Tap Tie-In to Transmission Main | 5d | 2027-03-11 | 2027-03-17 | CON-00110, CON-00100 | 20d | CON | PIP | GC |
|  | WBS-001.CON.05 | **Electrical and I&C** |  | 2027-02-03 | 2027-04-14 |  |  |  |  |  |
| CON-00130 |  | Set Electrical Switchgear and MCC | 10d | 2027-02-03 | 2027-02-17 | CON-00080, PRO-00050 | 5d | CON | ELE | SUB |
| CON-00140 |  | Install Electrical Conduit, Wire, and Lighting | 25d | 2027-02-18 | 2027-03-24 | CON-00130 | 5d | CON | ELE | SUB |
| CON-00160 |  | Install SCADA Instrumentation and Field Devices | 15d | 2027-03-11 | 2027-03-31 | CON-00080, CON-00100 | 0d | CON | EIN | SUB |
| CON-00150 |  | Set and Connect Standby Diesel Generator | 10d | 2027-03-25 | 2027-04-07 | PRO-00070, CON-00140 | 5d | CON | ELE | SUB |
| CON-00170 |  | Complete Electrical Terminations and Motor Wiring | 10d | 2027-04-01 | 2027-04-14 | CON-00100, CON-00090, CON-00140, CON-00160 | 0d | CON | EIN | SUB |
|  | WBS-001.COM | **Commissioning and Closeout** |  | 2027-04-15 | 2027-06-17 |  |  |  |  |  |
| COM-00010 |  | Perform Hydrostatic Testing — GST and Yard Piping | 5d | 2027-04-15 | 2027-04-21 | CON-00050, CON-00120, CON-00100, MIL-00050 | 0d | COM | MEC | GC |
| COM-00020 |  | Perform SCADA Integration and Loop Checks | 10d | 2027-04-15 | 2027-04-28 | CON-00170, CON-00150 | 5d | COM | EIN | SUB |
| COM-00030 |  | Perform Disinfection per AWWA C652 | 5d | 2027-04-22 | 2027-04-28 | COM-00010 | 0d | COM | MEC | GC |
| COM-00040 |  | Conduct Bacteriological Testing and Clearance | 5d | 2027-04-29 | 2027-05-05 | COM-00030 | 0d | COM | MEC | GC |
| COM-00050 |  | Perform Pump Start-Up and Performance Testing | 5d | 2027-05-06 | 2027-05-12 | COM-00040, COM-00020 | 0d | COM | MEC | SUB |
| COM-00060 |  | Complete Punchlist and Final Inspections | 15d | 2027-05-13 | 2027-06-03 | MIL-00060 | 0d | CLS | PMG | GC |
| COM-00070 |  | Deliver O&M Manuals and Record Drawings | 10d | 2027-06-04 | 2027-06-17 | MIL-00070 | 0d | CLS | PMG | EPC |

Notes:
- CON-00060: BSA Comments: Includes pump base pads, equipment pads, and anchor bolts; can start concurrent with GST foundation.
- CON-00070: BSA Comments: 2,400 SF CMU masonry walls and structural steel roof framing.
- CON-00080: BSA Comments: Metal roof, louvers, doors, and weatherproofing; building must be enclosed before equipment set.
- CON-00090: BSA Comments: Three 250-hp VTPs; requires building enclosed and pumps on site.
- CON-00110: BSA Comments: Approx 1,600 LF of 16-inch and 12-inch ductile iron yard piping; can proceed in parallel with building work.
- CON-00100: BSA Comments: Suction and discharge headers, isolation valves, check valves, pressure gauges inside pump station.
- CON-00120: BSA Comments: Hot-tap on live existing transmission main; requires district shutdown window coordination. Schedule as discrete activity after yard piping is complete. Confirm outage window with district operations. Removed dangling dependency reference to 'CON-00111' (no such activity) — review.
- CON-00130: BSA Comments: Requires building enclosed and switchgear on site.
- CON-00140: BSA Comments: Building power distribution, lighting, receptacles, grounding, and utility service entrance.
- CON-00160: BSA Comments: Flow meters, pressure transmitters, level transmitters, RTUs, and fiber/communication to district SCADA; requires piping and structural complete.
- CON-00150: BSA Comments: Generator pad must be complete; generator on site required.
- CON-00170: BSA Comments: Final power and control terminations to VTPs and all equipment; requires pumps set and piping complete.
- COM-00010: BSA Comments: Includes 24-hour hydrostatic test of GST per AWWA D110 and pressure testing of yard piping.
- COM-00020: BSA Comments: Point-to-point checks, motor wiring verification, loop checks, and integration test with district SCADA.
- COM-00030: BSA Comments: Chlorination of GST, yard piping, and pump station per AWWA C652; includes flush, dose, hold, and neutralize.
- COM-00040: BSA Comments: Two consecutive satisfactory bacteriological samples required by state regulatory authority before service.
- COM-00050: BSA Comments: Wet run of all three VTPs, generator load test, and SCADA operational verification. Open end — no successor; auto-wired to Substantial Completion — review.
- COM-00060: BSA Comments: Owner and engineer punchlist walkthrough, corrections, and final regulatory inspection.
- COM-00070: BSA Comments: As-built drawings, O&M manuals, warranties, and spare parts delivery to district.

## Activity codes

| Code | Value | Meaning |
| --- | --- | --- |
| Discipline | ARC | Architectural |
| Discipline | CIV | Civil |
| Discipline | EIN | Electrical / Instrumentation |
| Discipline | ELE | Electrical |
| Discipline | MEC | Mechanical |
| Discipline | PIP | Piping |
| Discipline | PMG | Project Management |
| Discipline | STR | Structural |
| Phase | CLS | Closeout |
| Phase | COM | Commissioning |
| Phase | CON | Construction |
| Phase | MLS | Milestone |
| Phase | PRO | Procurement |
| Responsibility | EPC | EPC Contractor |
| Responsibility | GC | General Contractor |
| Responsibility | OWN | Owner / Client |
| Responsibility | SUB | Subcontractor |
| Responsibility | VND | Vendor / Supplier |
