# Mainline Pump Upgrade — West Texas Pump Station

Schedule from Primavera P6, 2026-08-03 to 2027-08-06, data date 2026-08-03.

## Calendars

- BSA_5D_10H_HOL_US_CON: Mon-Fri 07:00-17:00; Sat-Sun off. Exceptions (off unless hours are given): 2026-09-07, 2026-11-26, 2026-12-25, 2027-01-01, 2027-01-18, 2027-05-31, 2027-06-18, 2027-07-05.

## Schedule

| ID | WBS | Activity | Type | Duration | Start | Finish | Predecessors | Total float | Phase | Discipline | Responsibility |
| --- | --- | --- | --- | --- | --- | --- | --- | --- | --- | --- | --- |
|  | TRM-001.MIL | **Milestones** |  |  | 2026-08-03 | 2027-08-06 |  |  |  |  |  |
| MIL-00010 |  | Notice to Proceed (NTP) | milestone | 0d | 2026-08-03 | 2026-08-03 |  | 0d | MLS | PMG | OWN |
| MIL-00020 |  | IFC Drawings Issued | milestone | 0d | 2026-09-30 | 2026-09-30 | ENG-00080 | 0d | MLS | PMG | OWN |
| MIL-00070 |  | Long-Lead POs Issued | milestone | 0d | 2026-10-01 | 2026-10-01 | MIL-00020 | 0d | PRO | MEC | OWN |
| MIL-00080 |  | All Long-Lead Equipment On Site | milestone | 0d | 2027-04-06 | 2027-04-06 | PRO-00030, PRO-00060, PRO-00090, PRO-00120 | 45d | MLS | PMG | GC |
| MIL-00030 |  | Mechanical Completion | milestone | 0d | 2027-06-09 | 2027-06-09 | MIL-00080, CON-00120 | 0d | MLS | PMG | OWN |
| MIL-00040 |  | Substantial Completion | milestone | 0d | 2027-07-09 | 2027-07-09 | COM-00040, COM-00020 | 0d | MLS | PMG | OWN |
| MIL-00050 |  | Ready for Service | milestone | 0d | 2027-07-23 | 2027-07-23 | COM-00050 | 0d | MLS | PMG | OWN |
| MIL-00060 |  | Final Completion | milestone | 0d | 2027-08-06 | 2027-08-06 | COM-00060 | 0d | MLS | PMG | OWN |
|  | TRM-001.ENG | **Engineering** |  |  | 2026-08-03 | 2026-09-30 |  |  |  |  |  |
| ENG-00010 |  | Perform Preliminary Design & Basis of Design |  | 15d | 2026-08-03 | 2026-08-21 | MIL-00010 | 0d | ENG | PMG | DES |
| ENG-00020 |  | Complete 30% Design — Civil, Structural & Building |  | 12d | 2026-08-24 | 2026-09-09 | ENG-00010 | 0d | ENG | CIV | DES |
| ENG-00030 |  | Complete 30% Design — Mechanical & Piping |  | 12d | 2026-08-24 | 2026-09-09 | ENG-00010 | 0d | ENG | MPP | DES |
| ENG-00040 |  | Complete 30% Design — Electrical & Instrumentation |  | 12d | 2026-08-24 | 2026-09-09 | ENG-00010 | 0d | ENG | EIN | DES |
| ENG-00050 |  | Complete 60% Design — Civil, Structural & Building |  | 10d | 2026-09-10 | 2026-09-23 | ENG-00020 | 0d | ENG | CIV | DES |
| ENG-00060 |  | Complete 60% Design — Mechanical & Piping |  | 10d | 2026-09-10 | 2026-09-23 | ENG-00030 | 0d | ENG | MPP | DES |
| ENG-00070 |  | Complete 60% Design — Electrical & Instrumentation |  | 10d | 2026-09-10 | 2026-09-23 | ENG-00040 | 0d | ENG | EIN | DES |
| ENG-00080 |  | Issue IFC Drawings — All Disciplines |  | 5d | 2026-09-24 | 2026-09-30 | ENG-00050, ENG-00060, ENG-00070 | 0d | ENG | PMG | DES |
|  | TRM-001.PRO | **Procurement** |  |  | 2026-10-01 | 2027-04-06 |  |  |  |  |  |
| PRO-00020 |  | Fabricate & Deliver Pump/Motor Skids |  | 130d | 2026-10-01 | 2027-04-06 | MIL-00070 | 0d | PRO | MEC | VND |
| PRO-00050 |  | Fabricate & Deliver VFDs |  | 100d | 2026-10-01 | 2027-02-23 | MIL-00070 | 43d | PRO | ELE | VND |
| PRO-00080 |  | Fabricate & Deliver Switchgear & MCC |  | 110d | 2026-10-01 | 2027-03-09 | MIL-00070 | 23d | PRO | ELE | VND |
| PRO-00110 |  | Fabricate & Deliver Pre-Engineered Building |  | 70d | 2026-10-01 | 2027-01-11 | MIL-00070 | 50d | PRO | STR | VND |
| PRO-00120 |  | Pre-Engineered Building On Site | milestone | 0d | 2027-01-11 | 2027-01-11 | PRO-00110 | 50d | PRO | STR | VND |
| PRO-00060 |  | VFDs On Site | milestone | 0d | 2027-02-23 | 2027-02-23 | PRO-00050 | 43d | PRO | ELE | VND |
| PRO-00090 |  | Switchgear & MCC On Site | milestone | 0d | 2027-03-09 | 2027-03-09 | PRO-00080 | 23d | PRO | ELE | VND |
| PRO-00030 |  | Pump/Motor Skids On Site | milestone | 0d | 2027-04-06 | 2027-04-06 | PRO-00020 | 0d | PRO | MEC | VND |

Notes:
- MIL-00020: BSA Comments: Milestone gates all procurement POs and construction start. Target ~10 weeks after NTP per narrative.
- MIL-00070: BSA Comments: PO gates the 26-week fabrication/delivery clock. Requires IFC mechanical data sheets.
- MIL-00080: BSA Comments: Rollup of every long-lead delivery — gates Mechanical Completion (BSA standard milestone set).
- ENG-00010: BSA Comments: Covers BOD, design criteria, equipment data sheets, and site survey; must complete before 30% design.
- ENG-00080: BSA Comments: Final IFC package. Duration covers checking, stamping, and distribution. Narrative states ~10 weeks after NTP; total ENG chain sums to ~50 working days which aligns.
- PRO-00020: BSA Comments: 26-week lead time per narrative (26 wks × 5 days = 130 working days). Vendor FAT recommended; schedule FAT hold point in bsa_comments. Skids are critical-path drivers.
- PRO-00050: BSA Comments: 20-week lead time per narrative (20 × 5 = 100 working days). VFDs to be installed in electrical building.
- PRO-00080: BSA Comments: 22-week lead time per narrative (22 × 5 = 110 working days). 4,160V equipment; confirm utility coordination for energization in bsa_comments.
- PRO-00110: BSA Comments: Assumed 14-week lead (70 working days). Erection cannot start until piers are complete AND building is on site.
- PRO-00120: BSA Comments: Delivery milestone; gates building erection.
- PRO-00060: BSA Comments: Delivery milestone; gates VFD installation.
- PRO-00090: BSA Comments: Delivery milestone; gates electrical building expansion and switchgear setting.
- PRO-00030: BSA Comments: Delivery milestone; gates skid setting. Confirm laydown area available in West Texas yard.

| ID | WBS | Activity | Duration | Start | Finish | Predecessors | Total float | Phase | Discipline | Responsibility |
| --- | --- | --- | --- | --- | --- | --- | --- | --- | --- | --- |
|  | TRM-001.CON | **Construction** |  | 2026-10-01 | 2027-06-09 |  |  |  |  |  |
| CON-00010 |  | Mobilize Contractor & Establish Site | 5d | 2026-10-01 | 2026-10-07 | MIL-00020 | 93d | CON | PMG | GC |
|  | TRM-001.CON.01 | **Civil & Structural** |  | 2026-10-08 | 2026-11-06 |  |  |  |  |  |
| CON-00030 |  | Drill & Install Drilled Piers — Pump Building | 12d | 2026-10-08 | 2026-10-23 | CON-00010 | 93d | CON | CIV | GC |
| CON-00060 |  | Expand Electrical Building — Civil & Structural | 10d | 2026-10-08 | 2026-10-21 | CON-00010 | 118d | CON | CIV | GC |
| CON-00040 |  | Form, Pour & Cure Pump Building Foundation | 10d | 2026-10-26 | 2026-11-06 | CON-00030 | 93d | CON | CIV | GC |
|  | TRM-001.CON.02 | **Mechanical — Pump Building & Skids** |  | 2027-01-12 | 2027-04-16 |  |  |  |  |  |
| CON-00050 |  | Erect Pre-Engineered Metal Building | 10d | 2027-01-12 | 2027-01-26 | CON-00040, PRO-00120 | 50d | CON | STR | GC |
| CON-00070 |  | Set & Grout Pump/Motor Skids (3 units) | 8d | 2027-04-07 | 2027-04-16 | CON-00050, PRO-00030 | 0d | CON | MEC | GC |
|  | TRM-001.CON.03 | **Station Piping** |  | 2027-04-19 | 2027-05-21 |  |  |  |  |  |
| CON-00080 |  | Install Station Piping — Suction & Discharge Headers | 20d | 2027-04-19 | 2027-05-14 | CON-00070, CON-00020 | 0d | CON | PIP | GC |
| CON-00130 |  | Hydrotest Station Piping | 5d | 2027-05-17 | 2027-05-21 | CON-00080 | 0d | CON | PIP | GC |
|  | TRM-001.CON.04 | **Electrical & Instrumentation** |  | 2027-03-10 | 2027-06-09 |  |  |  |  |  |
| CON-00090 |  | Install Electrical Building Equipment — MCC & Switchgear | 10d | 2027-03-10 | 2027-03-23 | CON-00060, PRO-00090 | 23d | CON | ELE | GC |
| CON-00100 |  | Install VFDs in Electrical Building | 5d | 2027-03-24 | 2027-03-30 | CON-00090, PRO-00060 | 23d | CON | ELE | GC |
| CON-00110 |  | Pull & Terminate Power & Control Cables | 15d | 2027-04-19 | 2027-05-07 | CON-00100, CON-00070 | 10d | CON | EIN | GC |
| CON-00120 |  | Install Instrumentation & Tie Into Station PLC | 12d | 2027-05-24 | 2027-06-09 | CON-00130, CON-00110 | 0d | CON | EIN | GC |
|  | TRM-001.CON.05 | **Demolition** |  | 2026-10-08 | 2026-10-21 |  |  |  |  |  |
| CON-00020 |  | Demolish Retired Pump Units (2 × 2,000 hp) | 10d | 2026-10-08 | 2026-10-21 | CON-00010 | 123d | CON | MEC | GC |
|  | TRM-001.COM | **Commissioning & Closeout** |  | 2027-06-10 | 2027-08-06 |  |  |  |  |  |
| COM-00010 |  | Execute Station Shutdown & Mainline Tie-In | 10d | 2027-06-10 | 2027-06-24 | CON-00130, MIL-00030 | 0d | COM | MPP | OWN |
| COM-00030 |  | Perform Commissioning & Start-Up | 10d | 2027-06-10 | 2027-06-24 | MIL-00030 | 6d | COM | MPP | GC |
| COM-00020 |  | Perform Pre-Commissioning & Loop Checks | 10d | 2027-06-25 | 2027-07-09 | CON-00120, COM-00010 | 0d | COM | EIN | GC |
| COM-00040 |  | Conduct 72-Hour Performance Test | 4d | 2027-06-25 | 2027-06-30 | COM-00030 | 6d | COM | MPP | OWN |
| COM-00050 |  | Complete Punchlist & Construction Closeout | 10d | 2027-07-12 | 2027-07-23 | MIL-00040 | 0d | CLS | PMG | GC |
| COM-00060 |  | Complete Project Closeout & Turnover Documents | 10d | 2027-07-26 | 2027-08-06 | MIL-00050 | 0d | CLS | PMG | OWN |

Notes:
- CON-00010: BSA Comments: Mobilization, temporary facilities, safety plan activation.
- CON-00030: BSA Comments: Drilled piers for 60×40 ft PEMB; typically 10–15 piers. Geo assumptions: caliche/rock typical West Texas; confirm boring data.
- CON-00060: BSA Comments: Foundation and structural expansion of existing electrical building to accommodate new MCC/switchgear. Can proceed in parallel with pump building civil work.
- CON-00040: BSA Comments: Grade beams and slab-on-grade atop drilled piers. Includes embedded anchor bolts for skid baseplates.
- CON-00050: BSA Comments: Structural steel, roof, and wall panels. Requires foundation complete and building delivered on site.
- CON-00070: BSA Comments: Precision alignment, shimming, and grouting of baseplate. Requires building enclosed and skids on site.
- CON-00080: BSA Comments: ~850 LF 16-in and 20-in CS piping, ~120 field welds. Weld inspection (RT/UT) included in duration. Can begin once building is enclosed and skids are set.
- CON-00130: BSA Comments: Pneumatic or hydrostatic test of new piping. Must follow piping installation and all welds; NDE results accepted before test.
- CON-00090: BSA Comments: Set, anchor, and bus 4,160V switchgear and MCC lineup. Requires electrical building expansion complete and switchgear on site.
- CON-00100: BSA Comments: Mount and land VFDs. Requires MCC/switchgear installed and VFDs on site.
- CON-00110: BSA Comments: MV and LV cables from switchgear/VFDs to pump motors and junction boxes. Can start once skids are set and MCC is installed. Final motor terminations after skids set.
- CON-00120: BSA Comments: Pressure, flow, temp, and vibration instruments; signal cabling; PLC I/O cards and programming changes. Requires piping near-complete for instrument taps.
- CON-00020: BSA Comments: Includes isolation, de-oiling, mechanical disconnection, and removal of retired units. Can proceed in parallel with civil work once site is mobilized.
- COM-00010: BSA Comments: 10-day planned mainline shutdown window for hot-tap or spool tie-in to existing 16-in/20-in headers. Owner coordinates with pipeline operations; shutdown window must be pre-approved. This is the schedule's highest-risk single activity.
- COM-00030: BSA Comments: Initial energization, pump start-up, control system checkout, lube oil system commissioning. Follows tie-in and pre-commissioning.
- COM-00020: BSA Comments: Point-to-point checks, megger tests, motor rotation, instrument loop calibration. Requires all electrical and instrumentation work complete. Open end — no successor; auto-wired to Substantial Completion — review.
- COM-00040: BSA Comments: 72-hour continuous run at rated conditions per performance test protocol. Owner and vendor witness. Approximately 3 working days at 10 h/day (3×10=30 h 72 h minus weekends); add 1 day buffer = 4 days.
- COM-00050: BSA Comments: Category A/B punchlist resolution, redlines, final inspection.
- COM-00060: BSA Comments: As-built drawings, O&M manuals, data books, regulatory submittals, final invoicing.

## Activity codes

| Code | Value | Meaning |
| --- | --- | --- |
| Discipline | CIV | Civil |
| Discipline | EIN | Electrical / Instrumentation |
| Discipline | ELE | Electrical |
| Discipline | MEC | Mechanical |
| Discipline | MPP | Mechanical / Piping |
| Discipline | PIP | Piping |
| Discipline | PMG | Project Management |
| Discipline | STR | Structural |
| Phase | CLS | Closeout |
| Phase | COM | Commissioning |
| Phase | CON | Construction |
| Phase | ENG | Engineering |
| Phase | MLS | Milestone |
| Phase | PRO | Procurement |
| Responsibility | DES | Designer / Engineer |
| Responsibility | GC | General Contractor |
| Responsibility | OWN | Owner / Client |
| Responsibility | VND | Vendor / Supplier |
